# HRA Project Plan

Schedule from MS Project, 2011-10-31 to 2012-12-17, A marks actual dates.
Microsoft

## Calendars

- Standard: Mon-Fri 08:00-12:00, 13:00-17:00; Sat-Sun off. Exceptions (off unless hours are given): 2011-11-24 (Thanksgiving Day), 2011-11-25 (Thanksgiving Friday), 2011-12-23 (Special MIT Holiday 1), 2011-12-26 (Christmas Day Observed), 2011-12-30 (Special MIT Holiday 2), 2012-01-02 (New Years Day Observed), 2012-01-16 (Martin Luther King Birthday), 2012-02-20 (Presidents Day).

## Resources

| Resource |
| --- |
| Ross |
| Jonathan |
| Robin |
| Janet |

## Schedule

| ID | WBS | Task | Type | Duration | Start | Finish | Predecessors | Complete | Remaining | Total slack | Constraint | Resources | Work | Actual work |
| --- | --- | --- | --- | --- | --- | --- | --- | --- | --- | --- | --- | --- | --- | --- |
| 1 | 1 | **Housing Replacement Analysis Project** |  | 288d? | 2011-10-31 A | 2012-12-17 |  | 32% | 196.09d? | 0d |  |  | 4805.52h | 1367.44h |
| 2 | 1.1 | Project Kickoff Meeting |  | 1d | 2011-10-31 | 2011-10-31 |  |  |  | 227d |  |  |  |  |
| 3 | 1.2 | **Discovery Phase (as-is)** |  | 199d? | 2011-11-04 A | 2012-08-20 |  | 78% | 44.29d? | 85d |  |  | 1891.92h | 1367.44h |
| 4 | 1.2.1 | **Business Justification** |  | 20d | 2011-11-04 A | 2011-12-06 A | 2 | 100% |  |  |  |  | 136h | 136h |
| 5 | 1.2.1.1 | Write Business Justification |  | 10d | 2011-11-14 A | 2011-11-25 A | 6 | 100% |  |  | start no earlier than 2011-11-01 | Jonathan | 80h | 80h |
| 6 | 1.2.1.2 | Review Business Justification |  | 6d | 2011-11-04 A | 2011-11-11 A |  | 100% |  |  | finish no earlier than 2011-11-11 | Jonathan | 48h | 48h |
| 7 | 1.2.1.3 | Obtain Approval from Project Team |  | 1d | 2011-11-29 A | 2011-11-29 A | 5, 6 | 100% |  |  | start no earlier than 2011-11-29 | Jonathan | 8h | 8h |
| 8 | 1.2.1.4 | Obtain Approval from Project Sponsors | milestone | 0d | 2011-12-06 A | 2011-12-06 A | 7 | 100% |  |  | start no earlier than 2011-12-06 | Jonathan |  |  |
| 9 | 1.2.1.5 | Business Justification completed | milestone | 0d | 2011-12-06 A | 2011-12-06 A | 8 | 100% |  |  |  | Jonathan |  |  |
| 10 | 1.2.2 | **Project Scope Document** |  | 19d | 2011-11-07 A | 2011-12-06 A | 2 | 100% |  |  |  |  | 56h | 56h |
| 11 | 1.2.2.1 | Write Project Scope Document |  | 5d | 2011-11-07 A | 2011-11-11 A |  | 100% |  |  | finish no earlier than 2011-11-11 | Jonathan | 40h | 40h |
| 12 | 1.2.2.2 | Review Project Scope Document |  | 1d | 2011-11-18 A | 2011-11-18 A | 11 | 100% |  |  | finish no earlier than 2011-11-18 | Jonathan | 8h | 8h |
| 13 | 1.2.2.3 | Obtain Approval from Project Team |  | 1d | 2011-11-29 A | 2011-11-29 A |  | 100% |  |  | start no earlier than 2011-11-29 | Jonathan | 8h | 8h |
| 14 | 1.2.2.4 | Obtain Approval from Project Sponsors | milestone | 0d | 2011-12-06 A | 2011-12-06 A |  | 100% |  |  | start no earlier than 2011-12-06 | Jonathan |  |  |
| 15 | 1.2.2.5 | Project Scope completed | milestone | 0d | 2011-12-06 A | 2011-12-06 A |  | 100% |  |  | start no earlier than 2011-12-06 | Jonathan |  |  |
| 16 | 1.2.3 | **Discovery Meetings** |  | 125d | 2011-12-15 A | 2012-06-14 A | 4, 10 | 100% |  |  |  |  | 811.2h | 811.2h |
| 17 | 1.2.3.1 | **Housing / Lottery** |  | 94d | 2011-12-15 A | 2012-05-02 A |  | 100% |  |  |  |  | 12.8h | 12.8h |
| 18 | 1.2.3.1.1 | Freshman (new to the Institute) |  | 2d | 2011-12-15 A | 2011-12-16 A |  | 100% |  |  | start no earlier than 2011-12-15 | Ross [40%] | 6.4h | 6.4h |
| 19 | 1.2.3.1.2 | Upperclassman |  | 1d | 2012-04-09 A | 2012-04-09 A |  | 100% |  |  | start no earlier than 2012-04-09 | Ross [40%] | 3.2h | 3.2h |
| 20 | 1.2.3.1.3 | Graduate Students |  | 1d | 2012-05-02 A | 2012-05-02 A |  | 100% |  |  | start no earlier than 2012-05-02 | Janet [40%] | 3.2h | 3.2h |
| 21 | 1.2.3.2 | **Housing filemaker Databases** |  | 10d | 2012-02-06 A | 2012-02-17 A |  | 100% |  |  |  |  | 232h | 232h |
| 22 | 1.2.3.2.1 | Master Blaster |  | 5d | 2012-02-06 A | 2012-02-10 A |  | 100% |  |  | start no earlier than 2012-02-06 | Janet | 40h | 40h |
| 23 | 1.2.3.2.2 | UG Confirmation |  | 5d | 2012-02-06 A | 2012-02-10 A |  | 100% |  |  | start no earlier than 2012-02-06 | Ross [40%] | 16h | 16h |
| 24 | 1.2.3.2.3 | Conference / Guest |  | 5d | 2012-02-06 A | 2012-02-10 A |  | 100% |  |  | start no earlier than 2012-02-06 | Ross [40%] | 16h | 16h |
| 25 | 1.2.3.2.4 | Vacancy |  | 5d | 2012-02-13 A | 2012-02-17 A |  | 100% |  |  | start no earlier than 2012-02-13 | Janet | 40h | 40h |
| 26 | 1.2.3.2.5 | Early Return |  | 5d | 2012-02-13 A | 2012-02-17 A |  | 100% |  |  | start no earlier than 2012-02-13 | Ross | 40h | 40h |
| 27 | 1.2.3.2.6 | Waiting List |  | 5d | 2012-02-13 A | 2012-02-17 A |  | 100% |  |  | start no earlier than 2012-02-13 | Janet | 40h | 40h |
| 28 | 1.2.3.2.7 | Front Desk |  | 5d | 2012-02-13 A | 2012-02-17 A |  | 100% |  |  | start no earlier than 2012-02-13 | Ross | 40h | 40h |
| 29 | 1.2.3.3 | Housing SISTIM Functionality on Housing |  | 8d | 2012-02-21 A | 2012-03-01 A |  | 100% |  |  | start no earlier than 2012-02-21 | Ross | 64h | 64h |
| 30 | 1.2.3.4 | Housing MITSIS Functionality on Housing |  | 8d | 2012-02-21 A | 2012-03-01 A |  | 100% |  |  | start no earlier than 2012-02-21 | Janet | 64h | 64h |

| ID | WBS | Task | Type | Duration | Start | Finish | Predecessors | Complete | Remaining | Total slack | Constraint | Resources | Work | Actual work |
| --- | --- | --- | --- | --- | --- | --- | --- | --- | --- | --- | --- | --- | --- | --- |
| 31 | 1.2.3.5 | **Housing Stakeholder - HFS Accounting (David Bull's Group)** |  | 5d | 2012-03-05 A | 2012-03-09 A | 30FS+1d | 100% |  |  |  |  | 240h | 240h |
| 32 | 1.2.3.5.1 | Discuss systems/applications/process flow |  | 5d | 2012-03-05 A | 2012-03-09 A |  | 100% |  |  |  | Janet | 40h | 40h |
| 33 | 1.2.3.5.2 | Discuss process calendar |  | 5d | 2012-03-05 A | 2012-03-09 A |  | 100% |  |  |  | Janet | 40h | 40h |
| 34 | 1.2.3.5.3 | Walkthrough of digital Building/Room Setup & Maintenance |  | 5d | 2012-03-05 A | 2012-03-09 A |  | 100% |  |  |  | Janet | 40h | 40h |
| 35 | 1.2.3.5.4 | Walkthrough of Room Rate Codes Setup & Maintenance |  | 5d | 2012-03-05 A | 2012-03-09 A |  | 100% |  |  |  | Janet | 40h | 40h |
| 36 | 1.2.3.5.5 | Analysis/review of OTF process |  | 5d | 2012-03-05 A | 2012-03-09 A |  | 100% |  |  |  | Janet | 40h | 40h |
| 37 | 1.2.3.5.6 | Discuss functionality/efficiency/information gaps in current assessment & OTF process |  | 5d | 2012-03-05 A | 2012-03-09 A |  | 100% |  |  |  | Janet | 40h | 40h |
| 38 | 1.2.3.6 | **Housing Stakeholder - Student Financial Services** |  | 5d | 2012-03-13 A | 2012-03-19 A | 31FS+1d | 100% |  |  |  |  | 48h | 48h |
| 39 | 1.2.3.6.1 | Assess primary users/roles |  | 5d | 2012-03-13 A | 2012-03-19 A |  | 100% |  |  |  | Ross [40%] | 16h | 16h |
| 40 | 1.2.3.6.2 | Discuss systems/process flow |  | 5d | 2012-03-13 A | 2012-03-19 A |  | 100% |  |  |  | Ross [40%] | 16h | 16h |
| 41 | 1.2.3.6.3 | Discuss process calendar |  | 5d | 2012-03-13 A | 2012-03-19 A |  | 100% |  |  |  | Ross [40%] | 16h | 16h |
| 42 | 1.2.3.7 | **Housing Stakeholder - Registrar** |  | 5d | 2012-03-21 A | 2012-03-27 A | 38FS+1d | 100% |  |  |  |  | 120h | 120h |
| 43 | 1.2.3.7.1 | Evaluate scope of affected data/process/systems |  | 5d | 2012-03-21 A | 2012-03-27 A |  | 100% |  |  |  | Janet | 40h | 40h |
| 44 | 1.2.3.7.2 | Examine dataflow for MITSIS Directory information |  | 5d | 2012-03-21 A | 2012-03-27 A |  | 100% |  |  |  | Janet | 40h | 40h |
| 45 | 1.2.3.7.3 | Examine current supporting processes & functionality |  | 5d | 2012-03-21 A | 2012-03-27 A |  | 100% |  |  |  | Janet | 40h | 40h |
| 46 | 1.2.3.8 | Housing Stakeholders - Card Office / SEMO I |  | 1d | 2012-03-23 A | 2012-03-23 A |  | 100% |  |  | start no earlier than 2012-03-23 | Ross [40%] | 3.2h | 3.2h |
| 47 | 1.2.3.9 | Housing Stakeholders - Campus Dining |  | 1d | 2012-04-04 A | 2012-04-04 A |  | 100% |  |  | start no earlier than 2012-04-04 | Ross [40%] | 3.2h | 3.2h |
| 48 | 1.2.3.10 | Housing Stakeholders - Tech Cash |  | 1d | 2012-04-04 A | 2012-04-04 A |  | 100% |  |  | start no earlier than 2012-04-04 | Janet [40%] | 3.2h | 3.2h |
| 49 | 1.2.3.11 | UG House Managers |  | 1d | 2012-04-12 A | 2012-04-12 A |  | 100% |  |  | start no earlier than 2012-04-12 | Ross [40%] | 3.2h | 3.2h |
| 50 | 1.2.3.12 | GRAD House Managers |  | 1d | 2012-04-17 A | 2012-04-17 A |  | 100% |  |  | start no earlier than 2012-04-17 | Janet [40%] | 3.2h | 3.2h |
| 51 | 1.2.3.13 | Housing Stakeholders - Card Office / SEMO II |  | 1d | 2012-04-23 A | 2012-04-23 A |  | 100% |  |  | start no earlier than 2012-04-23 | Janet | 8h | 8h |
| 52 | 1.2.3.14 | Dean On Call |  | 1d | 2012-06-14 A | 2012-06-14 A |  | 100% |  |  | start no earlier than 2012-06-14 | Ross [40%] | 3.2h | 3.2h |
| 53 | 1.2.3.15 | FSILG |  | 1d | 2012-05-15 A | 2012-05-15 A |  | 100% |  |  | start no earlier than 2012-05-15 | Janet [40%] | 3.2h | 3.2h |
| 54 | 1.2.4 | **Discovery Phase Documentation** |  | 93d? | 2012-04-09 A | 2012-08-15 |  | 61% | 36.57d? | 88d |  |  | 888.72h | 364.24h |
| 55 | 1.2.4.1 | **As-Is Business Process Descriptions** |  | 59d? | 2012-04-09 A | 2012-06-29 |  | 99% | 0d? | 122d |  |  | 324.8h | 201.6h |
| 56 | 1.2.4.1.1 | **Undergraduate Process** |  | 59d | 2012-04-09 A | 2012-06-29 |  | 99% | 0d | 122d |  |  | 126.4h | 126.4h |
| 57 | 1.2.4.1.1.1 | Undergraduate Process - Internal review (Spreadsheet) |  | 15d | 2012-04-09 A | 2012-04-27 A |  | 100% |  |  | finish no earlier than 2012-04-27 | Ross [40%] | 48h | 48h |
| 58 | 1.2.4.1.1.2 | Present Undergraduate Draft Version to Project Sponsor |  | 1d | 2012-05-04 A | 2012-05-04 A | 57, 62 | 100% |  |  | finish no earlier than 2012-05-04 | Ross [20%] | 1.6h | 1.6h |
| 59 | 1.2.4.1.1.3 | Undergraduate Process - Word Document - Internal Review |  | 23d | 2012-05-07 A | 2012-06-06 A | 58 | 100% |  |  | finish no earlier than 2012-06-06 | Ross [40%] | 73.6h | 73.6h |
| 60 | 1.2.4.1.1.4 | Present Undergarduate Process - Word Document to Project Sponsors |  | 1d | 2012-06-20 A | 2012-06-20 A | 59 | 100% |  |  | finish no earlier than 2012-06-20 | Ross [40%] | 3.2h | 3.2h |
| 61 | 1.2.4.1.1.5 | Obtain approval from Project Sponsors | milestone | 0d | 2012-06-29 | 2012-06-29 | 60 |  |  | 122d | start no earlier than 2012-06-29 | Jonathan |  |  |

| ID | WBS | Task | Type | Duration | Start | Finish | Predecessors | Complete | Remaining | Total slack | Free slack | Constraint | Resources | Work | Actual work |
| --- | --- | --- | --- | --- | --- | --- | --- | --- | --- | --- | --- | --- | --- | --- | --- |
| 62 | 1.2.4.1.2 | **Graduate Process** |  | 59d? | 2012-04-09 A | 2012-06-29 |  | 99% | 0d? | 122d |  |  | Janet [40%] | 198.4h | 75.2h |
| 63 | 1.2.4.1.2.1 | Graduate Process - Internal review |  | 15d | 2012-04-09 A | 2012-04-27 A |  | 100% |  |  |  | start no earlier than 2012-04-09 | Janet [40%] | 48h | 48h |
| 64 | 1.2.4.1.2.2 | Present Graduate Draft Version to Project Sponsor |  | 1d | 2012-05-21 A | 2012-05-21 A | 63 | 100% |  |  |  | start no earlier than 2012-05-21 | Janet [40%] | 3.2h | 3.2h |
| 65 | 1.2.4.1.2.3 | Graduate Process - Word Document - Internal Review |  | 1d | 2012-05-21 A | 2012-05-21 A |  | 100% |  |  |  | start no earlier than 2012-05-21 | Janet [40%] | 3.2h | 3.2h |
| 66 | 1.2.4.1.2.4 | Present Graduate Process - Word Document to Project Sponsors |  | 1d? | 2012-05-22 A | 2012-05-22 A | 63, 65 | 100% |  |  |  | start no earlier than 2012-05-21 | Janet [40%] | 3.2h | 3.2h |
| 67 | 1.2.4.1.2.5 | Obtain approval from Project Sponsors | milestone | 0d | 2012-06-29 | 2012-06-29 | 66 |  |  | 122d | 0d | start no earlier than 2012-06-29 | Jonathan |  |  |
| 68 | 1.2.4.1.3 | As-Is Busines Process Documentation completed | milestone | 0d | 2012-06-29 | 2012-06-29 | 67 |  |  | 122d |  | start no earlier than 2012-06-29 | Ross [40%]; Janet [40%] |  |  |
| 69 | 1.2.4.2 | **As-Is Process Maps (Visual Micrografx Process Maps)** |  | 55d | 2012-05-07 A | 2012-07-20 | 58 | 49% | 28.17d | 0d |  |  |  | 268.8h | 128h |
| 70 | 1.2.4.2.1 | Graduate Students - Internal review |  | 40d | 2012-05-07 A | 2012-06-29 |  | 50% | 20d | 15d |  | finish no earlier than 2012-06-29 | Janet [40%] | 128h | 64h |
| 71 | 1.2.4.2.2 | Undergraduate Students - Internal Review |  | 40d | 2012-05-07 A | 2012-06-29 |  | 50% | 20d | 5d |  | finish no earlier than 2012-06-29 | Ross [40%] | 128h | 64h |
| 72 | 1.2.4.2.3 | Present Draft Versions to Project Sponsor |  | 1d | 2012-07-18 | 2012-07-18 |  |  |  | -8d | 0d | start no earlier than 2012-07-18 | Janet [40%]; Ross [40%] | 6.4h |  |
| 73 | 1.2.4.2.4 | Updated completed versions after feedback from Project Sponsors |  | 1d | 2012-07-20 | 2012-07-20 |  |  |  | -10d | 0d | start no earlier than 2012-07-20 | Janet [40%]; Ross [40%] | 6.4h |  |
| 74 | 1.2.4.2.5 | As-Is Process Maps completed Signoff received | milestone | 0d | 2012-07-20 | 2012-07-20 | 73 |  |  | -10d | 0d |  | Jonathan |  |  |
| 75 | 1.2.4.3 | **System Diagram (IS&T)** |  | 55d | 2012-05-31 A | 2012-08-15 | 69 | 26% | 40.53d | 0d |  |  | Ross [44%] | 295.12h | 34.64h |
| 76 | 1.2.4.3.1 | High Level Picture |  | 20d | 2012-05-31 A | 2012-08-03 |  | 50% | 10d | 8d |  |  | Ross [40%] | 64h | 32h |
| 77 | 1.2.4.3.2 | Details - with Feeds, Interfaces, |  | 12d | 2012-07-23 | 2012-08-07 |  |  |  | 0d |  |  | Ross [40%] | 38.4h |  |
| 78 | 1.2.4.3.3 | Present Draft Versions to Project Sponsor |  | 1d | 2012-08-08 | 2012-08-08 | 77 |  |  | 0d |  |  |  |  |  |
| 79 | 1.2.4.3.4 | Updated completed versions after feedback from Project Sponsors |  | 5d | 2012-08-09 | 2012-08-15 | 78 |  |  | 0d |  |  |  |  |  |
| 80 | 1.2.4.3.5 | As-Is System Diagram completed | milestone | 0d | 2012-08-15 | 2012-08-15 | 79 |  |  | 0d |  |  |  |  |  |
| 81 | 1.2.5 | Review with Project Team, Stakeholders |  | 3d | 2012-08-16 | 2012-08-20 | 75 |  |  | 0d |  |  |  |  |  |
| 82 | 1.2.6 | Discovery Phase Completed | milestone | 0d | 2012-08-20 | 2012-08-20 | 81 |  |  | 0d |  |  |  |  |  |
| 83 | 1.3 | **Define Phase** |  | 63d | 2012-08-21 | 2012-11-15 | 82 |  |  | 0d |  |  |  | 2913.6h |  |
| 84 | 1.3.1 | **Identify stakeholder needs** |  | 20d | 2012-08-21 | 2012-09-17 |  |  |  | 0d |  |  |  | 1536h |  |
| 85 | 1.3.1.1 | Housing Central Office |  | 20d | 2012-08-21 | 2012-09-17 |  |  |  | 0d |  |  | Ross [40%]; Janet [40%] | 128h |  |
| 86 | 1.3.1.2 | Housing Managers |  | 20d | 2012-08-21 | 2012-09-17 |  |  |  | 0d |  |  | Ross [40%]; Janet [40%] | 128h |  |
| 87 | 1.3.1.3 | Housing Lottery |  | 20d | 2012-08-21 | 2012-09-17 |  |  |  | 0d |  |  | Ross [40%]; Janet [40%] | 128h |  |
| 88 | 1.3.1.4 | Housing Filemaker datbases |  | 20d | 2012-08-21 | 2012-09-17 |  |  |  | 0d |  |  | Ross [40%]; Janet [40%] | 128h |  |
| 89 | 1.3.1.5 | Undergraduate Housing |  | 20d | 2012-08-21 | 2012-09-17 |  |  |  | 0d |  |  | Ross [40%]; Janet [40%] | 128h |  |
| 90 | 1.3.1.6 | Graduate Housing |  | 20d | 2012-08-21 | 2012-09-17 |  |  |  | 0d |  |  | Ross [40%]; Janet [40%] | 128h |  |
| 91 | 1.3.1.7 | SFS |  | 20d | 2012-08-21 | 2012-09-17 |  |  |  | 0d |  |  | Ross [40%]; Janet [40%] | 128h |  |
| 92 | 1.3.1.8 | HFS |  | 20d | 2012-08-21 | 2012-09-17 |  |  |  | 0d |  |  | Ross [40%]; Janet [40%] | 128h |  |
| 93 | 1.3.1.9 | SEMO / Card Access |  | 20d | 2012-08-21 | 2012-09-17 |  |  |  | 0d |  |  | Ross [40%]; Janet [40%] | 128h |  |
| 94 | 1.3.1.10 | Campus Dining / Tech Cash |  | 20d | 2012-08-21 | 2012-09-17 |  |  |  | 0d |  |  | Ross [40%]; Janet [40%] | 128h |  |
| 95 | 1.3.1.11 | Deans on Call |  | 20d | 2012-08-21 | 2012-09-17 |  |  |  | 0d |  |  | Ross [40%]; Janet [40%] | 128h |  |
| 96 | 1.3.1.12 | FSILG |  | 20d | 2012-08-21 | 2012-09-17 |  |  |  | 0d |  |  | Ross [40%]; Janet [40%] | 128h |  |

Notes:
- 67: Robin received e-mail 2 days ago - she will approve by 6/29
- 69: Need to show calendar and stakeholders

| ID | WBS | Task | Duration | Start | Finish | Predecessors | Total slack | Free slack | Resources | Work |
| --- | --- | --- | --- | --- | --- | --- | --- | --- | --- | --- |
| 97 | 1.3.2 | **Review CBORD capabilities** | 15d | 2012-09-18 | 2012-10-08 | 84 | 0d |  | Ross [40%]; Janet [40%] | 224h |
| 98 | 1.3.2.1 | Review as-is of CBORD Odyssey today | 5d | 2012-09-18 | 2012-09-24 |  | 0d |  | Ross [40%]; Janet [40%] | 32h |
| 99 | 1.3.2.2 | Review where it can replace manual processes | 5d | 2012-09-25 | 2012-10-01 | 98 | 0d |  | Ross [40%]; Janet [40%] | 32h |
| 100 | 1.3.2.3 | Review as-is integration points | 5d | 2012-10-02 | 2012-10-08 | 99 | 0d |  | Ross [40%]; Janet [40%] | 32h |
| 101 | 1.3.2.4 | Training, Site-visit | 5d | 2012-09-18 | 2012-09-24 |  | 10d |  | Ross [40%]; Janet [40%] | 32h |
| 102 | 1.3.3 | **Out of Stakeholder Needs, Identify functional Specifications** | 12d | 2012-10-09 | 2012-10-24 | 97 | 22d | 0d | Ross [40%]; Janet [40%] | 998.4h |
| 103 | 1.3.3.1 | Housing Central Office | 12d | 2012-10-09 | 2012-10-24 |  | 22d |  | Ross [40%]; Janet [40%] | 76.8h |
| 104 | 1.3.3.2 | Housing Managers | 12d | 2012-10-09 | 2012-10-24 |  | 22d |  | Ross [40%]; Janet [40%] | 76.8h |
| 105 | 1.3.3.3 | Housing Lottery | 12d | 2012-10-09 | 2012-10-24 |  | 22d |  | Ross [40%]; Janet [40%] | 76.8h |
| 106 | 1.3.3.4 | Housing Filemaker datbases | 12d | 2012-10-09 | 2012-10-24 |  | 22d |  | Ross [40%]; Janet [40%] | 76.8h |
| 107 | 1.3.3.5 | Undergraduate Housing | 12d | 2012-10-09 | 2012-10-24 |  | 22d |  | Ross [40%]; Janet [40%] | 76.8h |
| 108 | 1.3.3.6 | Graduate Housing | 12d | 2012-10-09 | 2012-10-24 |  | 22d |  | Ross [40%]; Janet [40%] | 76.8h |
| 109 | 1.3.3.7 | SFS | 12d | 2012-10-09 | 2012-10-24 |  | 22d |  | Ross [40%]; Janet [40%] | 76.8h |
| 110 | 1.3.3.8 | HFS | 12d | 2012-10-09 | 2012-10-24 |  | 22d |  | Ross [40%]; Janet [40%] | 76.8h |
| 111 | 1.3.3.9 | SEMO / Card Access | 12d | 2012-10-09 | 2012-10-24 |  | 22d |  | Ross [40%]; Janet [40%] | 76.8h |
| 112 | 1.3.3.10 | Campus Dining / Tech Cash | 12d | 2012-10-09 | 2012-10-24 |  | 22d |  | Ross [40%]; Janet [40%] | 76.8h |
| 113 | 1.3.3.11 | Deans on Call | 12d | 2012-10-09 | 2012-10-24 |  | 22d |  | Ross [40%]; Janet [40%] | 76.8h |
| 114 | 1.3.3.12 | FSILG | 12d | 2012-10-09 | 2012-10-24 |  | 22d |  | Ross [40%]; Janet [40%] | 76.8h |
| 115 | 1.3.4 | Build wireframes | 5d | 2012-10-25 | 2012-10-31 | 102 | 22d | 0d | Ross [40%]; Janet [40%] | 32h |
| 116 | 1.3.5 | Create Functional Specifications | 5d | 2012-11-01 | 2012-11-07 | 115 | 22d | 0d | Ross; Janet [40%] | 56h |
| 117 | 1.3.6 | Review functionality with all stakeholders | 5d | 2012-11-08 | 2012-11-14 | 116 | 22d | 0d | Ross; Janet [40%] | 56h |
| 118 | 1.3.7 | Obtain approval from all stakeholders | 1d | 2012-11-15 | 2012-11-15 | 117 | 22d |  | Ross; Janet [40%] | 11.2h |
| 119 | 1.4 | Design Phase | 50d | 2012-10-09 | 2012-12-17 | 97 | 0d |  |  |  |
